# Residential Construction

Schedule from MS Project, 2018-07-19 to 2019-02-18.
Residential Construction
Instructions: Use this template for your next residential construction by add / deleting tasks, and resources to suit, and by adding in costs for resources and materials. Attach (using Insert Object) plans, estimates, receipts, etc. to appropriate line items.

## Calendars

- Standard: Mon-Fri 08:00-12:00, 13:00-17:00; Sat-Sun off.

## Resources

| Resource |
| --- |
| Concrete contractor |
| Finish carpentry contractor |
| Fencing contractor |
| Masonry contractor |
| General contractor |
| Architect |
| Owner |
| Mortgage lender |
| Inspector |
| Electric company |
| Site excavation contractor |
| Electric contractor |
| Plumbing contractor |
| Framing contractor |
| Roofing contractor |
| Heating and AC contractor |
| Insulation contractor |
| Drywall contractor |
| Painting contractor |
| Flooring contractor |
| Appliance contractor |
| Landscape contractor |
| Maid service |
| Building Material #1 (change to suite) |
| Building Material #2 (change to suite) |
| Building Material #3 (change to suite) |

## Schedule

| ID | WBS | Task | Type | Duration | Start | Finish | Predecessors | Total slack | Free slack | Resources | Work |
| --- | --- | --- | --- | --- | --- | --- | --- | --- | --- | --- | --- |
| 1 | 1 | **General Conditions** |  | 22d | 2018-07-19 | 2018-08-17 |  | 0d |  |  | 278.4h |
| 2 | 1.1 | Finalize plans, and develop estimate with owner and architect |  | 20d | 2018-07-19 | 2018-08-15 |  | 0d |  | General contractor [50%]; Architect [50%]; Owner [12%]; Mortgage lender [12%] | 198.4h |
| 3 | 1.2 | Sign contract & notice to proceed |  | 1d | 2018-08-16 | 2018-08-16 | 2 | 0d |  | General contractor; Architect; Owner; Mortgage lender | 32h |
| 4 | 1.3 | **Apply for Permits** |  | 1d | 2018-08-16 | 2018-08-17 |  | 0d |  |  | 48h |
| 5 | 1.3.1 | Secure foundation permit |  | 1d | 2018-08-17 | 2018-08-17 | 3 | 0d |  | General contractor | 8h |
| 6 | 1.3.2 | Secure framing permit |  | 1d | 2018-08-17 | 2018-08-17 | 3 | 0d |  | General contractor | 8h |
| 7 | 1.3.3 | Secure electrical permit |  | 1d | 2018-08-17 | 2018-08-17 | 3 | 0d |  | General contractor | 8h |
| 8 | 1.3.4 | Secure plumbing permit |  | 1d | 2018-08-17 | 2018-08-17 | 3 | 0d |  | General contractor | 8h |
| 9 | 1.3.5 | Secure HVAC permit |  | 1d | 2018-08-17 | 2018-08-17 | 3 | 0d |  | General contractor | 8h |
| 10 | 1.3.6 | Secure miscellaneous permits |  | 1d | 2018-08-17 | 2018-08-17 | 3 | 0d |  | General contractor | 8h |
| 11 | 1.3.7 | All Permits Secured | milestone | 0d | 2018-08-16 | 2018-08-16 | 3 | 132d | 0d |  |  |
| 12 | 2 | **Site Work** |  | 3d | 2018-08-20 | 2018-08-22 |  | 0d |  |  | 32h |
| 13 | 2.1 | Clear and grub lot |  | 1d | 2018-08-20 | 2018-08-20 | 5, 6, 7, 8, 10, 9 | 0d |  | Site excavation contractor | 8h |
| 14 | 2.2 | Install temporary power service |  | 1d | 2018-08-21 | 2018-08-21 | 13 | 0d |  | Electric company | 8h |
| 15 | 2.3 | Install underground utilities |  | 1d | 2018-08-22 | 2018-08-22 | 14 | 0d |  | Electric contractor; Plumbing contractor | 16h |
| 16 | 2.4 | All Site Work Complete | milestone | 0d | 2018-08-22 | 2018-08-22 | 15 | 0d |  |  |  |
| 17 | 3 | **Foundation** |  | 42d | 2018-08-23 | 2018-10-19 |  | 0d |  |  | 280h |
| 18 | 3.1 | Excavate for foundations |  | 3d | 2018-08-23 | 2018-08-27 | 16 | 0d |  | Site excavation contractor | 24h |
| 19 | 3.2 | Form basement walls |  | 13d | 2018-08-28 | 2018-09-13 | 18 | 0d |  | Concrete contractor | 104h |
| 20 | 3.3 | Place concrete for foundations & basement walls |  | 12d | 2018-09-14 | 2018-10-01 | 19 | 0d |  | Concrete contractor | 96h |
| 21 | 3.4 | Cure basement walls for 7 days |  | 7d | 2018-10-02 | 2018-10-10 | 20 | 0d |  |  |  |
| 22 | 3.5 | Strip basement wall forms |  | 2d | 2018-10-11 | 2018-10-12 | 21 | 0d |  | Concrete contractor | 16h |
| 23 | 3.6 | Waterproof/insulate basement walls |  | 2d | 2018-10-15 | 2018-10-16 | 22 | 0d |  | Concrete contractor | 16h |
| 24 | 3.7 | Perform foundation inspection |  | 1d | 2018-10-17 | 2018-10-17 | 23, 18 | 0d |  | Inspector | 8h |
| 25 | 3.8 | Backfill foundation |  | 2d | 2018-10-18 | 2018-10-19 | 24 | 0d |  | Site excavation contractor | 16h |
| 26 | 3.9 | Foundation Complete | milestone | 0d | 2018-10-19 | 2018-10-19 | 25 | 0d |  |  |  |

| ID | WBS | Task | Type | Duration | Start | Finish | Predecessors | Total slack | Free slack | Resources | Work |
| --- | --- | --- | --- | --- | --- | --- | --- | --- | --- | --- | --- |
| 27 | 4 | **Framing** |  | 22d | 2018-10-22 | 2018-11-20 |  | 0d |  |  | 176h |
| 28 | 4.1 | Install 1st floor joists |  | 2d | 2018-10-22 | 2018-10-23 | 26 | 0d |  | Framing contractor | 16h |
| 29 | 4.2 | Lay 1st floor decking |  | 2d | 2018-10-24 | 2018-10-25 | 28 | 0d |  | Framing contractor | 16h |
| 30 | 4.3 | Frame 1st floor walls |  | 4d | 2018-10-26 | 2018-10-31 | 29 | 0d |  | Framing contractor | 32h |
| 31 | 4.4 | Frame 1st floor corners |  | 1d | 2018-11-01 | 2018-11-01 | 30 | 0d |  | Framing contractor | 8h |
| 32 | 4.5 | Install 2nd floor joists |  | 2d | 2018-11-02 | 2018-11-05 | 31 | 0d |  | Framing contractor | 16h |
| 33 | 4.6 | Frame 2nd floor decking |  | 2d | 2018-11-06 | 2018-11-07 | 32 | 0d |  | Framing contractor | 16h |
| 34 | 4.7 | Frame 2nd floor walls |  | 3d | 2018-11-08 | 2018-11-12 | 33 | 0d |  | Framing contractor | 24h |
| 35 | 4.8 | Frame 2nd floor corners |  | 2d | 2018-11-13 | 2018-11-14 | 34 | 0d |  | Framing contractor | 16h |
| 36 | 4.9 | Complete roof framing |  | 3d | 2018-11-15 | 2018-11-19 | 35 | 0d |  | Framing contractor | 24h |
| 37 | 4.10 | Conduct framing inspection |  | 1d | 2018-11-20 | 2018-11-20 | 36 | 0d |  | Inspector | 8h |
| 38 | 4.11 | Framing Complete | milestone | 0d | 2018-11-20 | 2018-11-20 | 37 | 0d |  |  |  |
| 39 | 5 | **Dry In** |  | 22d | 2018-11-20 | 2018-12-19 |  | 1d | 0d |  | 152h |
| 40 | 5.1 | Install 1st floor sheathing |  | 3d | 2018-11-21 | 2018-11-23 | 38 | 0d |  | Framing contractor | 24h |
| 41 | 5.2 | Install 2nd floor sheathing |  | 3d | 2018-11-26 | 2018-11-28 | 40 | 0d |  | Framing contractor | 24h |
| 42 | 5.3 | Install roof decking |  | 3d | 2018-11-20 | 2018-11-22 | 36 | 4d | 0d | Framing contractor | 24h |
| 43 | 5.4 | Install felt, flashing and shingles |  | 3d | 2018-12-06 | 2018-12-10 | 53 | 0d |  | Roofing contractor | 24h |
| 44 | 5.5 | Hang 1st floor exterior doors |  | 1d | 2018-12-11 | 2018-12-11 | 43 | 0d |  | Framing contractor | 8h |
| 45 | 5.6 | Install 1st floor windows |  | 3d | 2018-12-12 | 2018-12-14 | 44 | 0d |  | Framing contractor | 24h |
| 46 | 5.7 | Install 2nd floor windows |  | 3d | 2018-12-17 | 2018-12-19 | 45 | 0d |  | Framing contractor | 24h |
| 47 | 5.8 | Dry In Complete | milestone | 0d | 2018-12-19 | 2018-12-19 | 46 | 5d | 0d |  |  |
| 48 | 6 | **Exterior Finishes** |  | 19d | 2018-12-20 | 2019-01-15 |  | 5d | 0d |  | 152h |
| 49 | 6.1 | Complete exterior brick |  | 16d | 2018-12-20 | 2019-01-10 | 47 | 5d | 0d | Masonry contractor | 128h |
| 50 | 6.2 | Complete exterior siding |  | 3d | 2019-01-11 | 2019-01-15 | 49 | 5d | 0d | Framing contractor | 24h |
| 51 | 6.3 | <Exterior Finishes Complete | milestone | 0d | 2019-01-15 | 2019-01-15 | 50 | 24d | 0d |  |  |

| ID | WBS | Task | Type | Duration | Start | Finish | Predecessors | Total slack | Free slack | Resources | Work |
| --- | --- | --- | --- | --- | --- | --- | --- | --- | --- | --- | --- |
| 52 | 7 | **Utility Rough-B97Ins and Complete Concrete** |  | 21d | 2018-11-23 | 2018-12-21 |  | 4d | 0d |  | 232h |
| 53 | 7.1 | Rough-in plumbing |  | 5d | 2018-11-29 | 2018-12-05 | 42, 41 | 0d |  | Plumbing contractor | 40h |
| 54 | 7.2 | Conduct rough-in plumbing inspection |  | 1d | 2018-12-06 | 2018-12-06 | 53 | 20d | 0d | Inspector | 8h |
| 55 | 7.3 | Place concrete for basement floor |  | 11d | 2018-12-07 | 2018-12-21 | 54 | 33d | 0d | Concrete contractor | 88h |
| 56 | 7.4 | Rough-in electrical |  | 5d | 2018-11-29 | 2018-12-05 | 42, 41 | 6d | 0d | Electric contractor | 40h |
| 57 | 7.5 | Conduct rough-in electrical inspection |  | 1d | 2018-12-06 | 2018-12-06 | 56 | 6d | 0d | Inspector | 8h |
| 58 | 7.6 | Rough-in HVAC |  | 3d | 2018-12-07 | 2018-12-11 | 57 | 6d | 0d | Heating and AC contractor | 24h |
| 59 | 7.7 | Conduct rough-in HVAC inspection |  | 1d | 2018-12-12 | 2018-12-12 | 58 | 24d | 0d | Inspector | 8h |
| 60 | 7.8 | Rough-in communication - phone, cable, computer, alarm |  | 2d | 2018-11-23 | 2018-11-26 | 42 | 17d | 0d | Electric contractor | 16h |
| 61 | 7.9 | Utility Rough-ins Complete | milestone | 0d | 2018-11-26 | 2018-11-26 | 60 | 60d | 0d |  |  |
| 62 | 8 | **Interior Finishes** |  | 30d | 2018-12-20 | 2019-01-30 |  | 0d |  |  | 408h |
| 63 | 8.1 | **Insulation** |  | 11d | 2018-12-20 | 2019-01-03 |  | 0d |  |  | 32h |
| 64 | 8.1.1 | Place wall insulation - 1st floor |  | 1d | 2018-12-20 | 2018-12-20 | 40, 46, 60, 58, 56, 41 | 0d |  | Insulation contractor | 8h |
| 65 | 8.1.2 | Place wall insulation - 2nd floor |  | 1d | 2018-12-21 | 2018-12-21 | 64 | 27d | 0d | Insulation contractor | 8h |
| 66 | 8.1.3 | Place ceiling insulation - 2nd floor |  | 1d | 2019-01-02 | 2019-01-02 | 72, 65 | 24d | 0d | Insulation contractor | 8h |
| 67 | 8.1.4 | Conduct insulation inspection |  | 1d | 2019-01-03 | 2019-01-03 | 66 | 24d | 0d | Inspector | 8h |
| 68 | 8.2 | **Drywall** |  | 9d | 2018-12-21 | 2019-01-02 |  | 0d |  |  | 80h |
| 69 | 8.2.1 | Install drywall - 1st floor walls |  | 2d | 2018-12-21 | 2018-12-24 | 64 | 0d |  | Drywall contractor | 16h |
| 70 | 8.2.2 | Install drywall - 1st floor overhead |  | 2d | 2018-12-25 | 2018-12-26 | 69 | 0d |  | Drywall contractor | 16h |
| 71 | 8.2.3 | Install drywall 2nd floor walls |  | 2d | 2018-12-27 | 2018-12-28 | 70, 65 | 24d | 0d | Drywall contractor | 16h |
| 72 | 8.2.4 | Install drywall 2nd floor overhead |  | 2d | 2018-12-31 | 2019-01-01 | 71 | 24d | 0d | Drywall contractor | 16h |
| 73 | 8.2.5 | Tape and float 1st floor drywall |  | 1d | 2018-12-27 | 2018-12-27 | 70 | 0d |  | Drywall contractor | 8h |
| 74 | 8.2.6 | Tape and float 2nd floor drywall |  | 1d | 2019-01-02 | 2019-01-02 | 72, 73 | 33d | 0d | Drywall contractor | 8h |
| 75 | 8.3 | **Paint and Wallpaper** |  | 17d | 2018-12-28 | 2019-01-21 |  | 0d |  |  | 72h |
| 76 | 8.3.1 | Texture all except entry and kitchen - 1st floor |  | 1d | 2018-12-28 | 2018-12-28 | 73 | 0d |  | Painting contractor | 8h |
| 77 | 8.3.2 | Paint all except entry and kitchen - 1st floor |  | 1d | 2018-12-31 | 2018-12-31 | 76 | 0d |  | Painting contractor | 8h |
| 78 | 8.3.3 | Hang wallpaper entry and kitchen - 1st floor |  | 1d | 2019-01-01 | 2019-01-01 | 77 | 0d |  | Painting contractor | 8h |
| 79 | 8.3.4 | Texture all - 2nd floor |  | 1d | 2018-12-31 | 2018-12-31 | 76 | 34d | 0d | Painting contractor | 8h |
| 80 | 8.3.5 | Paint all - 2nd floor |  | 1d | 2019-01-01 | 2019-01-01 | 79 | 34d | 0d | Painting contractor | 8h |
| 81 | 8.3.6 | Paint exterior siding & trim work |  | 4d | 2019-01-16 | 2019-01-21 | 50 | 5d | 0d | Painting contractor | 32h |

| ID | WBS | Task | Type | Duration | Start | Finish | Predecessors | Total slack | Free slack | Resources | Work |
| --- | --- | --- | --- | --- | --- | --- | --- | --- | --- | --- | --- |
| 82 | 8.4 | **Cabinets** |  | 6d | 2019-01-02 | 2019-01-09 |  | 0d |  |  | 48h |
| 83 | 8.4.1 | Install 1st floor - kitchen cabinets |  | 2d | 2019-01-02 | 2019-01-03 | 78 | 0d |  | Finish carpentry contractor | 16h |
| 84 | 8.4.2 | Install 1st floor - master bath and guest cabinets |  | 1d | 2019-01-04 | 2019-01-04 | 83 | 0d |  | Finish carpentry contractor | 8h |
| 85 | 8.4.3 | Install 2nd floor - hall bath and private bath cabinets |  | 1d | 2019-01-07 | 2019-01-07 | 84 | 1d | 0d | Finish carpentry contractor | 8h |
| 86 | 8.4.4 | Install chair rails, crown moldings, trim |  | 2d | 2019-01-08 | 2019-01-09 | 85 | 20d | 0d | Finish carpentry contractor | 16h |
| 87 | 8.5 | **Finish Plumbing** |  | 6d | 2019-01-04 | 2019-01-11 |  | 0d |  |  | 48h |
| 88 | 8.5.1 | Complete 1st floor - kitchen plumbing |  | 1d | 2019-01-04 | 2019-01-04 | 83, 54 | 0d |  | Plumbing contractor | 8h |
| 89 | 8.5.2 | Complete 1st floor - master bath and guest plumbing |  | 2d | 2019-01-07 | 2019-01-08 | 88, 84 | 0d |  | Plumbing contractor | 16h |
| 90 | 8.5.3 | Complete 2nd floor - hall bath and private bath plumbing |  | 2d | 2019-01-09 | 2019-01-10 | 89, 85 | 0d |  | Plumbing contractor | 16h |
| 91 | 8.5.4 | Conduct finish plumbing inspection |  | 1d | 2019-01-11 | 2019-01-11 | 90 | 0d |  | Inspector | 8h |
| 92 | 8.6 | **Finish Electrical** |  | 3d | 2019-01-11 | 2019-01-15 |  | 1d | 0d |  | 40h |
| 93 | 8.6.1 | Complete 1st floor circuits to service panel |  | 1d | 2019-01-11 | 2019-01-11 | 90, 57 | 3d | 0d | Electric contractor | 8h |
| 94 | 8.6.2 | Complete 2nd floor circuits to service panel |  | 1d | 2019-01-14 | 2019-01-14 | 93 | 3d | 0d | Electric contractor | 8h |
| 95 | 8.6.3 | Conduct finish electrical inspection |  | 1d | 2019-01-15 | 2019-01-15 | 94 | 3d | 0d | Inspector | 8h |
| 96 | 8.6.4 | Complete communications wiring - phone, cable, computer, alarm |  | 2d | 2019-01-14 | 2019-01-15 | 91 | 0d |  | Electric contractor | 16h |
| 97 | 8.7 | **Finish HVAC** |  | 3d | 2019-01-16 | 2019-01-18 |  | 0d |  |  | 24h |
| 98 | 8.7.1 | Complete 1st floor - zone 1 HVAC |  | 1d | 2019-01-16 | 2019-01-16 | 96, 59 | 0d |  | Heating and AC contractor | 8h |
| 99 | 8.7.2 | Complete 2nd floor - zone 2 HVAC |  | 1d | 2019-01-17 | 2019-01-17 | 98 | 0d |  | Heating and AC contractor | 8h |
| 100 | 8.7.3 | Conduct HVAC inspection |  | 1d | 2019-01-18 | 2019-01-18 | 99 | 0d |  | Inspector | 8h |
| 101 | 8.8 | **Carpet, Tile and Appliances** |  | 8d | 2019-01-21 | 2019-01-30 |  | 0d |  |  | 64h |
| 102 | 8.8.1 | Tile entry, kitchen and baths |  | 3d | 2019-01-21 | 2019-01-23 | 95, 100 | 0d |  | Flooring contractor | 24h |
| 103 | 8.8.2 | Carpet 1st floor |  | 2d | 2019-01-24 | 2019-01-25 | 102 | 0d |  | Flooring contractor | 16h |
| 104 | 8.8.3 | Carpet 2nd floor |  | 2d | 2019-01-28 | 2019-01-29 | 103 | 0d |  | Flooring contractor | 16h |
| 105 | 8.8.4 | Install appliances |  | 1d | 2019-01-30 | 2019-01-30 | 104 | 0d |  | Appliance contractor | 8h |
| 106 | 8.8.5 | Interior Finishes Complete | milestone | 0d | 2019-01-30 | 2019-01-30 | 105 | 13d | 0d |  |  |

| ID | WBS | Task | Type | Duration | Start | Finish | Predecessors | Total slack | Free slack | Resources | Work |
| --- | --- | --- | --- | --- | --- | --- | --- | --- | --- | --- | --- |
| 107 | 9 | **Landscaping and Grounds Work** |  | 12d | 2019-01-22 | 2019-02-06 |  | 0d |  |  | 56h |
| 108 | 9.1 | Pour concrete driveway and sidewalks |  | 2d | 2019-01-22 | 2019-01-23 | 81 | 5d | 0d | Concrete contractor | 16h |
| 109 | 9.2 | Install backyard fence |  | 2d | 2019-01-31 | 2019-02-01 | 105, 108 | 0d |  | Fencing contractor | 16h |
| 110 | 9.3 | Sod and complete plantings - front yard |  | 2d | 2019-02-04 | 2019-02-05 | 109 | 0d |  | Landscape contractor | 16h |
| 111 | 9.4 | Sod and complete plantings - backyard |  | 1d | 2019-02-06 | 2019-02-06 | 110 | 0d |  | Landscape contractor | 8h |
| 112 | 9.5 | Landscaping & Grounds Work Complete | milestone | 0d | 2019-02-06 | 2019-02-06 | 111 | 0d |  |  |  |
| 113 | 10 | **Final Acceptance** |  | 8d | 2019-02-07 | 2019-02-18 |  | 0d |  |  | 64h |
| 114 | 10.1 | Complete final inspection for certificate of occupancy |  | 1d | 2019-02-07 | 2019-02-07 | 100, 95, 91, 67, 86, 55, 112 | 0d |  | Inspector | 8h |
| 115 | 10.2 | Cleanup for occupancy |  | 1d | 2019-02-08 | 2019-02-08 | 105, 114 | 0d |  | Maid service | 8h |
| 116 | 10.3 | Perform final walk-through inspection |  | 1d | 2019-02-11 | 2019-02-11 | 115 | 0d |  | Owner | 8h |
| 117 | 10.4 | Complete punch list items |  | 5d | 2019-02-12 | 2019-02-18 | 116 | 0d |  | General contractor | 40h |
| 118 | 10.5 | Residential Construction Project Complete | milestone | 0d | 2019-02-18 | 2019-02-18 | 117 | 0d |  |  |  |
